# plannification_initiale_G1_E

Schedule from MS Project, 2019-02-11 to 2019-05-23, status date 2019-03-20, 7 hours a day, costs in €, A marks actual dates.

## Calendars

- Calendrier Projet Web: Mon 08:00-09:30; Tue-Sat 09:00-10:30; Sun off. Exceptions (off unless hours are given): 2019-02-25 to 2019-03-01 09:30-10:00, 14:30-15:00 (Vacance Hiver, recurring), 2019-04-22 to 2019-04-26 09:30-10:00, 14:30-15:00 (Vacance Avril, recurring).

## Resources

| Resource | Group | Rate |
| --- | --- | --- |
| BIETTE Rémi | Projet | 10 |
| HAAS Flavien | Projet | 10 |
| KOUMSAGA Carine | Projet | 10 |
| PALAFFRE Raphael | Projet | 10 |
| Client |  |  |

## Schedule

| ID | WBS | Task | Type | Duration | Start | Finish | Predecessors | Complete | Remaining | Baseline start | Baseline finish | Baseline duration | Total slack | Free slack | Constraint | Resources | Work | Actual work | Cost | Baseline cost | Actual cost |
| --- | --- | --- | --- | --- | --- | --- | --- | --- | --- | --- | --- | --- | --- | --- | --- | --- | --- | --- | --- | --- | --- |
| 1 | 1 | **Cahier des Charges** |  | 2.79d | 2019-02-11 A | 2019-02-26 |  | 99% | 0d | 2019-02-11 | 2019-02-26 | 2.79d | 0d |  | start no earlier than 2019-02-11 |  | 32h | 32h | 320 | 320 | 320 |
| 2 | 1.1 | Analyse de l'existant |  | 2h | 2019-02-11 A | 2019-02-12 A |  | 100% |  | 2019-02-11 | 2019-02-12 | 2h |  |  |  | KOUMSAGA Carine | 2h | 2h | 20 | 20 | 20 |
| 3 | 1.2 | **Fonctionnalités** |  | 0.86d | 2019-02-11 A | 2019-02-15 A |  | 100% |  | 2019-02-11 | 2019-02-15 | 0.86d |  |  |  |  | 10h | 10h | 100 | 100 | 100 |
| 4 | 1.2.1 | Module/Sous Parties |  | 3h | 2019-02-11 A | 2019-02-13 A |  | 100% |  | 2019-02-11 | 2019-02-13 | 3h |  |  |  | BIETTE Rémi; HAAS Flavien | 6h | 6h | 60 | 60 | 60 |
| 5 | 1.2.2 | Realisation Mockups |  | 3h | 2019-02-13 A | 2019-02-15 A | 4 | 100% |  | 2019-02-13 | 2019-02-15 | 3h |  |  |  | PALAFFRE Raphael | 3h | 3h | 30 | 30 | 30 |
| 6 | 1.2.3 | Spécifications des droits |  | 1h | 2019-02-13 A | 2019-02-14 A | 4 | 100% |  | 2019-02-13 | 2019-02-14 | 1h |  |  |  | BIETTE Rémi | 1h | 1h | 10 | 10 | 10 |
| 7 | 1.3 | Definitions des contraintes |  | 1h | 2019-02-15 A | 2019-02-16 A | 2, 3 | 100% |  | 2019-02-15 | 2019-02-16 | 1h |  |  |  | BIETTE Rémi; HAAS Flavien; KOUMSAGA Carine; PALAFFRE Raphael | 4h | 4h | 40 | 40 | 40 |
| 8 | 1.4 | Scénario d'utilisation |  | 2h | 2019-02-16 A | 2019-02-18 A | 7 | 100% |  | 2019-02-16 | 2019-02-18 | 2h |  |  |  | BIETTE Rémi; HAAS Flavien; KOUMSAGA Carine; PALAFFRE Raphael | 8h | 8h | 80 | 80 | 80 |
| 9 | 1.5 | Redaction Cahier des Charges |  | 2h | 2019-02-18 A | 2019-02-19 A | 8 | 100% |  | 2019-02-18 | 2019-02-19 | 2h |  |  |  | BIETTE Rémi; HAAS Flavien; KOUMSAGA Carine; PALAFFRE Raphael | 8h | 8h | 80 | 80 | 80 |
| 10 | 1.6 | Rendu cahier des charges | milestone | 0h | 2019-02-26 | 2019-02-26 |  |  |  | 2019-02-26 | 2019-02-26 | 0h | 0d |  | must finish on 2019-02-26 |  |  |  |  |  |  |
| 11 | 2 | **Conception** |  | 5.86d | 2019-02-27 A | 2019-03-30 | 1 | 71% | 1.71d | 2019-02-27 | 2019-04-01 | 6d | 0.14d | 0d |  |  | 156h | 93h | 1,560 | 1,580 | 930 |
| 12 | 2.1 | Conception Web |  | 15h | 2019-02-27 A | 2019-03-11 A |  | 100% |  | 2019-02-27 | 2019-03-14 | 20h |  |  |  | HAAS Flavien; PALAFFRE Raphael | 30h | 30h | 300 | 400 | 300 |
| 13 | 2.2 | Conception BD 1 |  | 15h | 2019-02-27 A | 2019-03-11 A |  | 100% |  | 2019-02-27 | 2019-03-11 | 15h |  |  |  | BIETTE Rémi; KOUMSAGA Carine | 30h | 30h | 300 | 300 | 300 |
| 14 | 2.3 | Conception PHP |  | 15h | 2019-03-11 A | 2019-03-22 | 13, 12 | 55% | 6.75h | 2019-03-15 | 2019-03-23 | 12h | 0.43d | 0d |  | BIETTE Rémi; HAAS Flavien; KOUMSAGA Carine; PALAFFRE Raphael | 60h | 33h | 600 | 480 | 330 |
| 15 | 2.4 | Validation MCD 1 | milestone | 0h | 2019-03-21 | 2019-03-21 |  |  |  | 2019-03-21 | 2019-03-21 | 0h | 0d |  | must start on 2019-03-21 |  |  |  |  |  |  |
| 16 | 2.5 | Conception BD 2 |  | 6h | 2019-03-22 | 2019-03-27 | 15, 14 |  |  | 2019-03-25 | 2019-03-30 | 8h | 0.43d | 0d |  | BIETTE Rémi; HAAS Flavien; KOUMSAGA Carine; PALAFFRE Raphael | 24h |  | 240 | 320 |  |
| 17 | 2.6 | Validation MCD 2 | milestone | 0h | 2019-03-28 | 2019-03-28 | 15 |  |  | 2019-03-28 | 2019-03-28 | 0h | 0d |  | must start on 2019-03-28 |  |  |  |  |  |  |
| 18 | 2.7 | Réalisation du Dossier de Conception |  | 3h | 2019-03-27 | 2019-03-29 | 12, 16 |  |  | 2019-03-30 | 2019-04-01 | 2h | 0.43d |  |  | BIETTE Rémi; HAAS Flavien; KOUMSAGA Carine; PALAFFRE Raphael | 12h |  | 120 | 80 |  |
| 19 | 2.8 | Rendu dossier de conception | milestone | 0h | 2019-03-30 | 2019-03-30 |  |  |  | 2019-03-30 | 2019-03-30 | 0h | 0d |  | must finish on 2019-03-30 |  |  |  |  |  |  |
| 20 | 3 | **Développement** |  | 8.5d | 2019-04-01 | 2019-05-17 | 11 |  |  | 2019-04-01 | 2019-05-18 | 8.5d | 0.14d | 0d |  |  | 184h |  | 1,840 | 1,700 |  |
| 21 | 3.1 | **Developpement Page Web** |  | 3.43d | 2019-04-01 | 2019-04-18 |  |  |  | 2019-04-01 | 2019-04-19 | 3.43d | 0.14d | 0d |  |  | 89h |  | 890 | 750 |  |
| 22 | 3.1.1 | HTML |  | 24h | 2019-04-01 | 2019-04-18 |  |  |  | 2019-04-01 | 2019-04-19 | 24h | 0.14d | 0d |  | HAAS Flavien [50%]; KOUMSAGA Carine [50%]; PALAFFRE Raphael [50%]; BIETTE Rémi [50%] | 41h |  | 410 | 410 |  |
| 23 | 3.1.2 | CSS |  | 24h | 2019-04-01 | 2019-04-18 |  |  |  | 2019-04-01 | 2019-04-13 | 17h | 0.14d | 0d |  | HAAS Flavien [50%]; PALAFFRE Raphael [50%]; KOUMSAGA Carine [50%]; BIETTE Rémi [50%] | 48h |  | 480 | 340 |  |
| 24 | 3.2 | Developpement BD |  | 14h | 2019-04-19 | 2019-05-01 | 22, 23 |  |  | 2019-04-19 | 2019-05-01 | 14h | 1.71d | 1.57d |  | BIETTE Rémi [50%]; HAAS Flavien [50%]; KOUMSAGA Carine; PALAFFRE Raphael | 28h |  | 280 | 280 |  |
| 25 | 3.3 | Developpement PHP |  | 25h | 2019-04-19 | 2019-05-09 | 21 |  |  | 2019-04-19 | 2019-05-10 | 25h | 0.14d | 0d |  | BIETTE Rémi [50%]; HAAS Flavien [50%] | 25h |  | 250 | 250 |  |

| ID | WBS | Task | Type | Duration | Start | Finish | Predecessors | Baseline start | Baseline finish | Baseline duration | Total slack | Free slack | Constraint | Resources | Work | Cost | Baseline cost |
| --- | --- | --- | --- | --- | --- | --- | --- | --- | --- | --- | --- | --- | --- | --- | --- | --- | --- |
| 26 | 3.4 | **Phase de test** |  | 1.5d | 2019-05-09 | 2019-05-17 | 21, 24, 25 | 2019-05-10 | 2019-05-18 | 1.5d | 0.14d |  |  |  | 42h | 420 | 420 |
| 27 | 3.4.1 | Description des scénarios de test |  | 2.5h | 2019-05-09 | 2019-05-11 |  | 2019-05-10 | 2019-05-11 | 2.5h | 0.14d | 0d |  | BIETTE Rémi; HAAS Flavien; KOUMSAGA Carine; PALAFFRE Raphael | 10h | 100 | 100 |
| 28 | 3.4.2 | Correction de bugs |  | 8h | 2019-05-11 | 2019-05-17 | 27 | 2019-05-13 | 2019-05-18 | 8h | 0.14d |  |  | BIETTE Rémi; HAAS Flavien; KOUMSAGA Carine; PALAFFRE Raphael | 32h | 320 | 320 |
| 29 | 4 | Preparation Soutenance |  | 5.5h | 2019-05-17 | 2019-05-22 | 20 | 2019-05-18 | 2019-05-22 | 5.5h | 0.14d |  |  | BIETTE Rémi; HAAS Flavien; KOUMSAGA Carine; PALAFFRE Raphael | 22h | 220 | 220 |
| 30 | 5 | Soutenance | milestone | 0h | 2019-05-23 | 2019-05-23 |  | 2019-05-23 | 2019-05-23 | 0h | 0d |  | must start on 2019-05-23 |  |  |  |  |
